# Оптимизация персонала

Schedule from MS Project, 2009-04-02 to 2009-06-05, status date 2009-05-25, costs in грн., A marks actual dates.
home

## Calendars

- Стандартный: Mon-Fri 09:00-13:00, 14:00-18:00; Sat-Sun off.

## Resources

| Resource | Unit | Rate |
| --- | --- | --- |
| менеджер по персоналу |  | 10.5 |
| менеджер проекта |  | 45.5 |
| сотрудник отдела кадров |  | 25 |
| ИКТ | шт. |  |
| ПО | шт. |  |
| Мебель | шт. |  |
| Канцелярские принадлежности | шт. |  |
| Директора подразделений |  | 40 |
| Аналитик |  | 30 |
| Высшее руководство |  | 80 |
| Личные данные о сотруниках |  |  |
| Телефон |  |  |
| Технолог |  |  |

## Schedule

| ID | WBS | Task | Duration | Start | Finish | Predecessors | Complete | Remaining | Baseline start | Baseline finish | Baseline duration | Total slack | Constraint | Resources | Work | Actual work | Cost | Baseline cost | Actual cost |
| --- | --- | --- | --- | --- | --- | --- | --- | --- | --- | --- | --- | --- | --- | --- | --- | --- | --- | --- | --- |
| 1 | 1 | **Методи управління людьськими ресурсами** | 47d | 2009-04-02 A | 2009-06-05 |  | 89% | 5.29d | 2009-04-02 | 2009-06-05 | 47d | 0d |  |  | 1044h | 800h | 36,386 | 36,386 | 25,436 |
| 2 | 1.1 | **Аналіз поточної ситуації на підприємстві** | 4d | 2009-04-02 A | 2009-04-07 A |  | 100% |  | 2009-04-02 | 2009-04-07 | 4d |  |  |  | 56h | 56h | 1,200 | 1,200 | 1,200 |
| 3 | 1.1.1 | Аналіз присутності замовлень | 1d | 2009-04-02 A | 2009-04-02 A |  | 100% |  | 2009-04-02 | 2009-04-02 | 1d |  | finish no earlier than 2009-04-02 | Директора подразделений; ИКТ [1 шт.] | 8h | 8h | 320 | 320 | 320 |
| 4 | 1.1.2 | Оцінка обсягу робіт | 1d | 2009-04-03 A | 2009-04-03 A | 3 | 100% |  | 2009-04-03 | 2009-04-03 | 1d |  |  | ИКТ [1 шт.]; Технолог | 8h | 8h |  |  |  |
| 5 | 1.1.3 | Оцінка трудомісткості робіт | 1d | 2009-04-02 A | 2009-04-02 A | 3, 4 | 100% |  | 2009-04-02 | 2009-04-02 | 1d |  | start no earlier than 2009-04-03 | Технолог; ИКТ [1 шт.] | 8h | 8h |  |  |  |
| 6 | 1.1.4 | Оцінка якості робіт | 1d | 2009-04-03 A | 2009-04-03 A | 3, 5 | 100% |  | 2009-04-03 | 2009-04-03 | 1d |  | start no earlier than 2009-04-03 | Директора подразделений; ИКТ [1 шт.] | 8h | 8h | 320 | 320 | 320 |
| 7 | 1.1.5 | Визначеня виконавців робіт | 1d | 2009-04-03 A | 2009-04-03 A | 3 | 100% |  | 2009-04-03 | 2009-04-03 | 1d |  | start no earlier than 2009-04-03 | Технолог; ИКТ [1 шт.] | 8h | 8h |  |  |  |
| 8 | 1.1.6 | Аналіз строків виконання робіт | 1d | 2009-04-06 A | 2009-04-06 A | 7 | 100% |  | 2009-04-06 | 2009-04-06 | 1d |  |  | Директора подразделений; ИКТ [1 шт.] | 8h | 8h | 320 | 320 | 320 |
| 9 | 1.1.7 | Висновки | 1d | 2009-04-07 A | 2009-04-07 A | 8 | 100% |  | 2009-04-07 | 2009-04-07 | 1d |  |  | Аналитик; ИКТ [1 шт.] | 8h | 8h | 240 | 240 | 240 |
| 10 | 1.2 | **Планування проекту** | 7d | 2009-04-08 A | 2009-04-16 A |  | 100% |  | 2009-04-08 | 2009-04-16 | 7d |  |  |  | 96h | 96h | 5,096 | 5,096 | 5,096 |
| 11 | 1.2.1 | Вормування мети проекту | 1d | 2009-04-08 A | 2009-04-08 A | 9 | 100% |  | 2009-04-08 | 2009-04-08 | 1d |  | start no earlier than 2009-04-08 | Высшее руководство; ИКТ [1 шт.]; Мебель [1 шт.]; ПО [1 шт.] | 8h | 8h | 640 | 640 | 640 |
| 12 | 1.2.2 | Формування стратегії та методів | 1d | 2009-04-08 A | 2009-04-08 A | 9, 11 | 100% |  | 2009-04-08 | 2009-04-08 | 1d |  | start no earlier than 2009-04-08 | Высшее руководство; ИКТ [1 шт.]; Мебель [1 шт.]; ПО [1 шт.] | 8h | 8h | 640 | 640 | 640 |
| 13 | 1.2.3 | розробка стратегії фінансування | 1d | 2009-04-08 A | 2009-04-08 A | 9, 12 | 100% |  | 2009-04-08 | 2009-04-08 | 1d |  | start no earlier than 2009-04-08 | Аналитик; ИКТ [1 шт.]; Мебель [1 шт.]; ПО [1 шт.] | 8h | 8h | 240 | 240 | 240 |
| 14 | 1.2.4 | Призначення керівника проекту | 1d | 2009-04-10 A | 2009-04-10 A | 13 | 100% |  | 2009-04-10 | 2009-04-10 | 1d |  | start no earlier than 2009-04-09 | Высшее руководство; Канцелярские принадлежности [1 шт.] | 8h | 8h | 640 | 640 | 640 |
| 15 | 1.2.5 | Формування документації з проекту | 2d | 2009-04-10 A | 2009-04-13 A | 14 | 100% |  | 2009-04-10 | 2009-04-13 | 2d |  |  | ИКТ [1 шт.]; ПО [1 шт.]; Мебель [1 шт.]; Канцелярские принадлежности [1 шт.] |  |  |  |  |  |
| 16 | 1.2.6 | Планування бюджету | 1d | 2009-04-10 A | 2009-04-10 A | 13, 15 | 100% |  | 2009-04-10 | 2009-04-10 | 1d |  | start no earlier than 2009-04-10 | Мебель [1 шт.]; менеджер проекта; ИКТ [1 шт.]; ПО [1 шт.] | 8h | 8h | 364 | 364 | 364 |
| 17 | 1.2.7 | Планування строків | 1d | 2009-04-13 A | 2009-04-13 A | 14, 16, 15 | 100% |  | 2009-04-13 | 2009-04-13 | 1d |  | start no earlier than 2009-04-10 | менеджер проекта; ИКТ [1 шт.]; ПО [1 шт.] | 8h | 8h | 364 | 364 | 364 |
| 18 | 1.2.8 | Планування операцій | 1d | 2009-04-13 A | 2009-04-13 A | 14, 16, 15 | 100% |  | 2009-04-13 | 2009-04-13 | 1d |  | start no earlier than 2009-04-10 | менеджер проекта; менеджер по персоналу; ИКТ [1 шт.]; ПО [1 шт.] | 16h | 16h | 448 | 448 | 448 |
| 19 | 1.2.9 | Затвердження бюджету | 1d | 2009-04-14 A | 2009-04-14 A | 18 | 100% |  | 2009-04-14 | 2009-04-14 | 1d |  |  | Высшее руководство; ИКТ [1 шт.]; ПО [1 шт.] | 8h | 8h | 640 | 640 | 640 |
| 20 | 1.2.10 | Затвердження строків | 1d | 2009-04-14 A | 2009-04-14 A | 17 | 100% |  | 2009-04-14 | 2009-04-14 | 1d |  |  | Высшее руководство; ИКТ [1 шт.]; ПО [1 шт.] | 8h | 8h | 640 | 640 | 640 |
| 21 | 1.2.11 | Аналіз ризиків | 1d | 2009-04-15 A | 2009-04-15 A | 14, 16, 20 | 100% |  | 2009-04-15 | 2009-04-15 | 1d |  | start no earlier than 2009-04-10 | Аналитик; ИКТ [1 шт.]; Мебель [1 шт.]; ПО [1 шт.] | 8h | 8h | 240 | 240 | 240 |
| 22 | 1.2.12 | Розробка мироприємств з мінімізації ризиків | 1d | 2009-04-16 A | 2009-04-16 A | 21 | 100% |  | 2009-04-16 | 2009-04-16 | 1d |  | start no earlier than 2009-04-10 | Аналитик; ИКТ [1 шт.]; ПО [1 шт.] | 8h | 8h | 240 | 240 | 240 |
| 23 | 1.3 | **Аналіз ситуації з персоналом** | 3d | 2009-04-17 A | 2009-04-21 A |  | 100% |  | 2009-04-17 | 2009-04-21 | 3d |  |  |  | 64h | 64h | 1,536 | 1,536 | 1,536 |
| 24 | 1.3.1 | Аналіз кваліфікації персоналу | 1d | 2009-04-17 A | 2009-04-17 A | 22 | 100% |  | 2009-04-17 | 2009-04-17 | 1d |  | start no earlier than 2009-04-14 | менеджер по персоналу; Директора подразделений; Личные данные о сотруниках | 16h | 16h | 404 | 404 | 404 |
| 25 | 1.3.2 | Аналіх характеристии працівника | 1d | 2009-04-20 A | 2009-04-20 A | 24 | 100% |  | 2009-04-20 | 2009-04-20 | 1d |  | start no earlier than 2009-04-14 | менеджер по персоналу; Личные данные о сотруниках | 8h | 8h | 84 | 84 | 84 |
| 26 | 1.3.3 | Аналіз прогнозованого обсягу робіт | 1d | 2009-04-21 A | 2009-04-21 A | 25 | 100% |  | 2009-04-21 | 2009-04-21 | 1d |  |  | Аналитик; ИКТ [1 шт.]; ПО [1 шт.]; Директора подразделений | 16h | 16h | 560 | 560 | 560 |
| 27 | 1.3.4 | Аналіз робіт закріпленних за кожним працівником | 1d | 2009-04-20 A | 2009-04-20 A | 26 | 100% |  | 2009-04-20 | 2009-04-20 | 1d |  | start no earlier than 2009-04-14 | менеджер по персоналу; ИКТ [1 шт.] | 8h | 8h | 84 | 84 | 84 |
| 28 | 1.3.5 | Аналіз кваліфікації персоналу | 1d | 2009-04-20 A | 2009-04-20 A | 27 | 100% |  | 2009-04-20 | 2009-04-20 | 1d |  | start no earlier than 2009-04-14 | менеджер по персоналу; ИКТ [1 шт.] | 8h | 8h | 84 | 84 | 84 |
| 29 | 1.3.6 | Аналіз поточної діяльності співробітника | 1d | 2009-04-20 A | 2009-04-20 A | 28 | 100% |  | 2009-04-20 | 2009-04-20 | 1d |  | start no earlier than 2009-04-14 | Директора подразделений; ИКТ [1 шт.] | 8h | 8h | 320 | 320 | 320 |

| ID | WBS | Task | Duration | Start | Finish | Predecessors | Complete | Baseline start | Baseline finish | Baseline duration | Constraint | Resources | Work | Actual work | Cost | Baseline cost | Actual cost |
| --- | --- | --- | --- | --- | --- | --- | --- | --- | --- | --- | --- | --- | --- | --- | --- | --- | --- |
| 30 | 1.4 | **Планування вивільнення ресурсів** | 8d | 2009-04-21 A | 2009-04-30 A |  | 100% | 2009-04-21 | 2009-04-30 | 8d |  |  | 272h | 272h | 9,172 | 9,172 | 9,172 |
| 31 | 1.4.1 | **Вибір об єкту реалізації проекту** | 2d | 2009-04-21 A | 2009-04-22 A |  | 100% | 2009-04-21 | 2009-04-22 | 2d |  |  | 24h | 24h | 880 | 880 | 880 |
| 32 | 1.4.1.1 | Аналіз показників підрозділів | 1d | 2009-04-21 A | 2009-04-21 A | 29 | 100% | 2009-04-21 | 2009-04-21 | 1d |  | ИКТ [1 шт.]; Аналитик | 8h | 8h | 240 | 240 | 240 |
| 33 | 1.4.1.2 | Аналіз специфіки роботи підрозділу | 1d | 2009-04-22 A | 2009-04-22 A | 32 | 100% | 2009-04-22 | 2009-04-22 | 1d | start no earlier than 2009-04-20 | Директора подразделений; ИКТ [1 шт.] | 8h | 8h | 320 | 320 | 320 |
| 34 | 1.4.1.3 | Аналіз виконання робіт працівниками підрозділу | 1d | 2009-04-21 A | 2009-04-21 A | 29, 33 | 100% | 2009-04-21 | 2009-04-21 | 1d | start no earlier than 2009-04-16 | Директора подразделений; ИКТ [1 шт.] | 8h | 8h | 320 | 320 | 320 |
| 35 | 1.4.2 | **Визначення методів управління персоналом** | 1d | 2009-04-22 A | 2009-04-22 A |  | 100% | 2009-04-22 | 2009-04-22 | 1d |  | Директора подразделений; менеджер по персоналу | 40h | 40h | 1,524 | 1,524 | 1,524 |
| 36 | 1.4.2.1 | Пошук існуючих методів вивільнення | 1d | 2009-04-22 A | 2009-04-22 A | 34 | 100% | 2009-04-22 | 2009-04-22 | 1d | start no earlier than 2009-04-17 | Аналитик; ИКТ [1 шт.] | 8h | 8h | 240 | 240 | 240 |
| 37 | 1.4.2.2 | Аналіз специфіки підприємства | 1d | 2009-04-22 A | 2009-04-22 A | 34, 36 | 100% | 2009-04-22 | 2009-04-22 | 1d | start no earlier than 2009-04-17 | Высшее руководство; ИКТ [1 шт.] | 8h | 8h | 640 | 640 | 640 |
| 38 | 1.4.2.3 | Вибір найбільш підходящого методу | 1d | 2009-04-22 A | 2009-04-22 A | 34, 37 | 100% | 2009-04-22 | 2009-04-22 | 1d | start no earlier than 2009-04-17 | Аналитик; ИКТ [1 шт.] | 8h | 8h | 240 | 240 | 240 |
| 39 | 1.4.3 | **Визначення критеріїв вивільнення** | 1d | 2009-04-22 A | 2009-04-22 A |  | 100% | 2009-04-22 | 2009-04-22 | 1d |  | менеджер по персоналу; Личные данные о сотруниках | 32h | 32h | 1,204 | 1,204 | 1,204 |
| 40 | 1.4.3.1 | Пошук існуючих методів вивільнення | 1d | 2009-04-22 A | 2009-04-22 A | 34 | 100% | 2009-04-22 | 2009-04-22 | 1d | start no earlier than 2009-04-17 | ИКТ [1 шт.]; Аналитик | 8h | 8h | 240 | 240 | 240 |
| 41 | 1.4.3.2 | Аналіз специфіки підприємства | 1d | 2009-04-22 A | 2009-04-22 A | 34, 40 | 100% | 2009-04-22 | 2009-04-22 | 1d | start no earlier than 2009-04-17 | Высшее руководство; ИКТ [1 шт.] | 8h | 8h | 640 | 640 | 640 |
| 42 | 1.4.3.3 | Вибір найбільш підходящого критерию | 1d | 2009-04-22 A | 2009-04-22 A | 34, 41 | 100% | 2009-04-22 | 2009-04-22 | 1d | start no earlier than 2009-04-17 | Аналитик; ИКТ [1 шт.] | 8h | 8h | 240 | 240 | 240 |
| 43 | 1.4.4 | **Анализ обранного метода** | 1d | 2009-04-23 A | 2009-04-23 A |  | 100% | 2009-04-23 | 2009-04-23 | 1d |  | Директора подразделений; менеджер проекта | 56h | 56h | 1,884 | 1,884 | 1,884 |
| 44 | 1.4.4.1 | Аналіз ступеня застосування | 1d | 2009-04-23 A | 2009-04-23 A | 38 | 100% | 2009-04-23 | 2009-04-23 | 1d | start no earlier than 2009-04-20 | Аналитик; ИКТ [1 шт.] | 8h | 8h | 240 | 240 | 240 |
| 45 | 1.4.4.2 | Аналіз необхідних данних | 1d | 2009-04-23 A | 2009-04-23 A | 38, 44 | 100% | 2009-04-23 | 2009-04-23 | 1d | start no earlier than 2009-04-20 | Аналитик; ИКТ [1 шт.] | 8h | 8h | 240 | 240 | 240 |
| 46 | 1.4.4.3 | аналіз специфіки застосування | 1d | 2009-04-23 A | 2009-04-23 A | 38, 45 | 100% | 2009-04-23 | 2009-04-23 | 1d | start no earlier than 2009-04-20 | Аналитик; ИКТ [1 шт.] | 8h | 8h | 240 | 240 | 240 |
| 47 | 1.4.4.4 | Аналіз недоліків | 1d | 2009-04-23 A | 2009-04-23 A | 38, 46 | 100% | 2009-04-23 | 2009-04-23 | 1d | start no earlier than 2009-04-20 | Аналитик; ИКТ [1 шт.] | 8h | 8h | 240 | 240 | 240 |
| 48 | 1.4.4.5 | Аналіз необхідних ресурсів | 1d | 2009-04-23 A | 2009-04-23 A | 38, 47 | 100% | 2009-04-23 | 2009-04-23 | 1d | start no earlier than 2009-04-20 | Аналитик; ИКТ [1 шт.] | 8h | 8h | 240 | 240 | 240 |
| 49 | 1.4.5 | **Аналіз обранного критерія** | 1d | 2009-04-23 A | 2009-04-23 A |  | 100% | 2009-04-23 | 2009-04-23 | 1d |  |  | 40h | 40h | 1,200 | 1,200 | 1,200 |
| 50 | 1.4.5.1 | Аналіз ступеня застосування | 1d | 2009-04-23 A | 2009-04-23 A | 42, 48 | 100% | 2009-04-23 | 2009-04-23 | 1d | start no earlier than 2009-04-20 | Аналитик; ИКТ [1 шт.] | 8h | 8h | 240 | 240 | 240 |
| 51 | 1.4.5.2 | Аналіз необхідних данних | 1d | 2009-04-23 A | 2009-04-23 A | 42, 50 | 100% | 2009-04-23 | 2009-04-23 | 1d | start no earlier than 2009-04-20 | ИКТ [1 шт.]; Аналитик | 8h | 8h | 240 | 240 | 240 |
| 52 | 1.4.5.3 | Аналіз специфіки застосування | 1d | 2009-04-23 A | 2009-04-23 A | 42, 51 | 100% | 2009-04-23 | 2009-04-23 | 1d | start no earlier than 2009-04-20 | Аналитик; ИКТ [1 шт.] | 8h | 8h | 240 | 240 | 240 |
| 53 | 1.4.5.4 | Аналіз об єктивності розрахунків | 1d | 2009-04-23 A | 2009-04-23 A | 42, 52 | 100% | 2009-04-23 | 2009-04-23 | 1d | start no earlier than 2009-04-20 | ИКТ [1 шт.]; Аналитик | 8h | 8h | 240 | 240 | 240 |
| 54 | 1.4.5.5 | Аналіз обмежень | 1d | 2009-04-23 A | 2009-04-23 A | 42, 53 | 100% | 2009-04-23 | 2009-04-23 | 1d | start no earlier than 2009-04-20 | Аналитик; ИКТ [1 шт.] | 8h | 8h | 240 | 240 | 240 |

| ID | WBS | Task | Duration | Start | Finish | Predecessors | Complete | Baseline start | Baseline finish | Baseline duration | Constraint | Resources | Work | Actual work | Cost | Baseline cost | Actual cost |
| --- | --- | --- | --- | --- | --- | --- | --- | --- | --- | --- | --- | --- | --- | --- | --- | --- | --- |
| 55 | 1.4.6 | **Аналіз необхідних данних** | 1d | 2009-04-24 A | 2009-04-24 A |  | 100% | 2009-04-24 | 2009-04-24 | 1d |  |  | 24h | 24h | 720 | 720 | 720 |
| 56 | 1.4.6.1 | Можливість застосування | 1d | 2009-04-24 A | 2009-04-24 A | 54 | 100% | 2009-04-24 | 2009-04-24 | 1d | start no earlier than 2009-04-21 | ИКТ [1 шт.]; Аналитик | 8h | 8h | 240 | 240 | 240 |
| 57 | 1.4.6.2 | Оцінка способу одержання | 1d | 2009-04-24 A | 2009-04-24 A | 54, 56 | 100% | 2009-04-24 | 2009-04-24 | 1d | start no earlier than 2009-04-21 | Аналитик; ИКТ [1 шт.] | 8h | 8h | 240 | 240 | 240 |
| 58 | 1.4.6.3 | Оцінка строків одеожання | 1d | 2009-04-24 A | 2009-04-24 A | 54, 57 | 100% | 2009-04-24 | 2009-04-24 | 1d | start no earlier than 2009-04-21 | ИКТ [1 шт.]; Аналитик | 8h | 8h | 240 | 240 | 240 |
| 59 | 1.4.7 | Визначення джерела | 1d | 2009-04-27 A | 2009-04-27 A | 58 | 100% | 2009-04-27 | 2009-04-27 | 1d |  | Аналитик; ИКТ [1 шт.] | 8h | 8h | 240 | 240 | 240 |
| 60 | 1.4.8 | **Математичний розрахунок критерія** | 1d | 2009-04-28 A | 2009-04-28 A |  | 100% | 2009-04-28 | 2009-04-28 | 1d |  |  | 24h | 24h | 720 | 720 | 720 |
| 61 | 1.4.8.1 | Вибір формули розрахунку | 1d | 2009-04-28 A | 2009-04-28 A | 59 | 100% | 2009-04-28 | 2009-04-28 | 1d | start no earlier than 2009-04-23 | ИКТ [1 шт.]; Аналитик | 8h | 8h | 240 | 240 | 240 |
| 62 | 1.4.8.2 | Підстановка необхідних данних | 1d | 2009-04-28 A | 2009-04-28 A | 59, 61 | 100% | 2009-04-28 | 2009-04-28 | 1d | start no earlier than 2009-04-23 | Аналитик; ИКТ [1 шт.] | 8h | 8h | 240 | 240 | 240 |
| 63 | 1.4.8.3 | Вивід кінцевого результату | 1d | 2009-04-28 A | 2009-04-28 A | 59, 62 | 100% | 2009-04-28 | 2009-04-28 | 1d | start no earlier than 2009-04-23 | ИКТ [1 шт.]; Аналитик | 8h | 8h | 240 | 240 | 240 |
| 64 | 1.4.9 | Аналіз результатів | 1d | 2009-04-29 A | 2009-04-29 A | 63 | 100% | 2009-04-29 | 2009-04-29 | 1d |  | Аналитик; ИКТ [1 шт.] | 8h | 8h | 240 | 240 | 240 |
| 65 | 1.4.10 | Підготовка аналітичного висновку | 1d | 2009-04-29 A | 2009-04-29 A | 63, 64 | 100% | 2009-04-29 | 2009-04-29 | 1d | start no earlier than 2009-04-24 | ИКТ [1 шт.]; Аналитик | 8h | 8h | 240 | 240 | 240 |
| 66 | 1.4.11 | Аналіз висновку вищим керівництвом | 1d | 2009-04-30 A | 2009-04-30 A | 65 | 100% | 2009-04-30 | 2009-04-30 | 1d |  | Директора подразделений; ИКТ [1 шт.] | 8h | 8h | 320 | 320 | 320 |
| 67 | 1.5 | **Проце вивільнення персоналу** | 11d | 2009-05-01 A | 2009-05-15 A |  | 100% | 2009-05-01 | 2009-05-15 | 11d |  |  | 232h | 232h | 7,092 | 7,092 | 7,092 |
| 68 | 1.5.1 | Підготовка роспорядження про початок проекту | 1d | 2009-05-01 A | 2009-05-01 A | 66 | 100% | 2009-05-01 | 2009-05-01 | 1d |  | ИКТ [1 шт.]; ПО [1 шт.]; Высшее руководство | 8h | 8h | 640 | 640 | 640 |
| 69 | 1.5.2 | Затвердження роспорядження | 1d | 2009-05-04 A | 2009-05-04 A | 68 | 100% | 2009-05-04 | 2009-05-04 | 1d | start no earlier than 2009-04-28 | Канцелярские принадлежности [1 шт.]; Высшее руководство | 8h | 8h | 640 | 640 | 640 |
| 70 | 1.5.3 | Підготовка необхідної документації | 1d | 2009-05-05 A | 2009-05-05 A | 69 | 100% | 2009-05-05 | 2009-05-05 | 1d |  | сотрудник отдела кадров; ИКТ [1 шт.]; ПО [1 шт.] | 8h | 8h | 200 | 200 | 200 |
| 71 | 1.5.4 | Підписання документації | 1d | 2009-05-06 A | 2009-05-06 A | 70 | 100% | 2009-05-06 | 2009-05-06 | 1d |  | Канцелярские принадлежности [1 шт.]; Директора подразделений | 8h | 8h | 320 | 320 | 320 |
| 72 | 1.5.5 | Формування пропозиції для працівника | 2d | 2009-05-06 A | 2009-05-07 A | 70, 71 | 100% | 2009-05-06 | 2009-05-07 | 2d | start no earlier than 2009-04-30 | ИКТ [1 шт.]; ПО [1 шт.]; менеджер по персоналу | 16h | 16h | 168 | 168 | 168 |
| 73 | 1.5.6 | Повідомлення працівника | 1d | 2009-05-08 A | 2009-05-08 A | 72 | 100% | 2009-05-08 | 2009-05-08 | 1d | start no earlier than 2009-05-05 | Телефон; менеджер по персоналу | 16h | 16h | 84 | 84 | 84 |
| 74 | 1.5.7 | оформлення документації | 1d | 2009-05-08 A | 2009-05-08 A | 72 | 100% | 2009-05-08 | 2009-05-08 | 1d | start no earlier than 2009-05-05 | сотрудник отдела кадров; ИКТ [1 шт.]; ПО [1 шт.] | 8h | 8h | 200 | 200 | 200 |
| 75 | 1.5.8 | Ротація кадрів | 5d | 2009-05-11 A | 2009-05-15 A | 74 | 100% | 2009-05-11 | 2009-05-15 | 5d | start no earlier than 2009-04-28 | Директора подразделений; менеджер проекта | 80h | 80h | 3,420 | 3,420 | 3,420 |
| 76 | 1.5.9 | Скорочення штату | 5d | 2009-05-11 A | 2009-05-15 A | 74, 75 | 100% | 2009-05-11 | 2009-05-15 | 5d | start no earlier than 2009-04-29 | менеджер по персоналу; сотрудник отдела кадров | 80h | 80h | 1,420 | 1,420 | 1,420 |
| 77 | 1.6 | **Складання резерву** | 6d | 2009-05-18 A | 2009-05-25 A |  | 100% | 2009-05-18 | 2009-05-25 | 6d |  |  | 80h | 80h | 1,340 | 1,340 | 1,340 |
| 78 | 1.6.1 | Прогнозування необхідності працівників | 1d | 2009-05-18 A | 2009-05-18 A | 76 | 100% | 2009-05-18 | 2009-05-18 | 1d | finish no earlier than 2009-05-13 | Аналитик; ИКТ [1 шт.]; ПО [1 шт.] | 8h | 8h | 240 | 240 | 240 |
| 79 | 1.6.2 | Оцінкуа фінансових можливостей підприємства | 1d | 2009-05-19 A | 2009-05-19 A | 78 | 100% | 2009-05-19 | 2009-05-19 | 1d | start no earlier than 2009-05-19 | Аналитик; ИКТ [1 шт.] | 8h | 8h | 240 | 240 | 240 |
| 80 | 1.6.3 | Розробка вимог | 1d | 2009-05-20 A | 2009-05-20 A | 79 | 100% | 2009-05-20 | 2009-05-20 | 1d |  | менеджер по персоналу; ИКТ [1 шт.]; ПО [1 шт.] | 8h | 8h | 84 | 84 | 84 |
| 81 | 1.6.4 | Оцінка важливості робіт | 0.5d | 2009-05-21 A | 2009-05-21 A | 79, 80 | 100% | 2009-05-21 | 2009-05-21 | 0.5d | start no earlier than 2009-05-13 | Директора подразделений; ИКТ [1 шт.]; Технолог | 8h | 8h | 160 | 160 | 160 |
| 82 | 1.6.5 | Оцінка вимог робітї | 1d | 2009-05-20 A | 2009-05-20 A | 81 | 100% | 2009-05-20 | 2009-05-20 | 1d | start no earlier than 2009-05-13 | Технолог; ИКТ [1 шт.] | 8h | 8h |  |  |  |
| 83 | 1.6.6 | Розробка пропозоцій працівнику | 1d | 2009-05-21 A | 2009-05-21 A | 82 | 100% | 2009-05-21 | 2009-05-21 | 1d | start no earlier than 2009-05-15 | ПО [1 шт.]; ИКТ [1 шт.]; менеджер по персоналу | 8h | 8h | 84 | 84 | 84 |
| 84 | 1.6.7 | Аналіз вимог та пропозицій | 1d | 2009-05-20 A | 2009-05-20 A | 79, 83 | 100% | 2009-05-20 | 2009-05-20 | 1d | start no earlier than 2009-05-14 | менеджер проекта; ИКТ [1 шт.]; ПО [1 шт.] | 8h | 8h | 364 | 364 | 364 |
| 85 | 1.6.8 | Формуваня контактних данних | 1d | 2009-05-22 A | 2009-05-22 A | 84, 83 | 100% | 2009-05-22 | 2009-05-22 | 1d | start no earlier than 2009-05-18 | менеджер по персоналу; ИКТ [1 шт.]; ПО [1 шт.]; Телефон | 16h | 16h | 84 | 84 | 84 |
| 86 | 1.6.9 | Розміщення контактних данних | 1d | 2009-05-25 A | 2009-05-25 A | 85 | 100% | 2009-05-25 | 2009-05-25 | 1d |  | ИКТ [1 шт.]; ПО [1 шт.]; менеджер по персоналу | 8h | 8h | 84 | 84 | 84 |

| ID | WBS | Task | Duration | Start | Finish | Predecessors | Complete | Remaining | Baseline start | Baseline finish | Baseline duration | Total slack | Free slack | Constraint | Resources | Work | Actual work | Cost | Baseline cost |
| --- | --- | --- | --- | --- | --- | --- | --- | --- | --- | --- | --- | --- | --- | --- | --- | --- | --- | --- | --- |
| 87 | 1.7 | **Закінчення проекту** | 5d | 2009-05-26 | 2009-06-01 |  |  |  | 2009-05-26 | 2009-06-01 | 5d | 3.5d |  |  |  | 88h |  | 4,158 | 4,158 |
| 88 | 1.7.1 | Аналіз проведених робіт | 1d | 2009-05-26 A | 2009-05-26 A | 86 | 100% |  | 2009-05-26 | 2009-05-26 | 1d |  |  | start no earlier than 2009-05-22 | менеджер проекта; Аналитик; Высшее руководство | 24h | 24h | 1,244 | 1,244 |
| 89 | 1.7.2 | Оцінка ефективності проекту | 1d | 2009-05-27 A | 2009-05-27 A | 88 | 100% |  | 2009-05-27 | 2009-05-27 | 1d |  |  | start no earlier than 2009-05-27 | Высшее руководство; ИКТ [1 шт.] | 8h | 8h | 640 | 640 |
| 90 | 1.7.3 | Аналіз ситуації з персоналом | 0.33d | 2009-05-27 A | 2009-05-27 | 88 | 99% | 0d | 2009-05-27 | 2009-05-27 | 0.33d | 7.67d |  | start no earlier than 2009-05-27 | менеджер по персоналу; Высшее руководство; Директора подразделений; ИКТ [1 шт.] | 8h | 7.92h | 348 | 348 |
| 91 | 1.7.4 | Аналіз відповідності робіт кваліфікації | 0.5d | 2009-05-27 A | 2009-05-27 A | 88, 90 | 100% |  | 2009-05-27 | 2009-05-27 | 0.5d |  |  | start no earlier than 2009-05-26 | менеджер по персоналу; Директора подразделений; ИКТ [1 шт.] | 8h | 8h | 202 | 202 |
| 92 | 1.7.5 | Оцінка роботи підприємства | 1d | 2009-05-29 A | 2009-05-29 A | 91 | 100% |  | 2009-05-29 | 2009-05-29 | 1d |  |  | start no earlier than 2009-05-29 | Аналитик; ИКТ [1 шт.] | 8h | 8h | 240 | 240 |
| 93 | 1.7.6 | Аналіз бюджету | 1d | 2009-06-01 | 2009-06-01 | 92 |  |  | 2009-06-01 | 2009-06-01 | 1d | 4d |  | start no earlier than 2009-05-25 | Аналитик; ИКТ [1 шт.]; ПО [1 шт.]; менеджер проекта | 16h |  | 604 | 604 |
| 94 | 1.7.7 | Аналіз строків проекту | 1d | 2009-06-01 | 2009-06-01 | 92, 93 |  |  | 2009-06-01 | 2009-06-01 | 1d | 4d |  | start no earlier than 2009-06-01 | ИКТ [1 шт.]; ПО [1 шт.]; Аналитик; Высшее руководство | 16h |  | 880 | 880 |
| 95 | 1.8 | **Аналіз отриманих результатів** | 5d | 2009-06-01 | 2009-06-05 |  |  |  | 2009-06-01 | 2009-06-05 | 5d | 0d |  |  | Аналитик; Высшее руководство; ИКТ [1.06 шт.]; ПО [1.06 шт.]; менеджер проекта | 156h |  | 6,792 | 6,792 |
| 96 | 1.8.1 | Аналіз обсягів робіт | 1d | 2009-06-01 | 2009-06-01 | 92 |  |  | 2009-06-01 | 2009-06-01 | 1d | 2d | 0d |  | Директора подразделений; ИКТ [1 шт.] | 8h |  | 320 | 320 |
| 97 | 1.8.2 | Аналіз компетентності персоналу | 1d | 2009-06-02 | 2009-06-02 | 96 |  |  | 2009-06-02 | 2009-06-02 | 1d | 3d |  | start no earlier than 2009-06-02 | менеджер по персоналу; ИКТ [1 шт.] | 8h |  | 84 | 84 |
| 98 | 1.8.3 | Аналіз завантаження персоналу | 0.5d | 2009-06-04 | 2009-06-04 | 96, 97 |  |  | 2009-06-04 | 2009-06-04 | 0.5d | 1.5d |  | start no earlier than 2009-06-04 | Технолог; ИКТ [1 шт.] | 4h |  |  |  |
| 99 | 1.8.4 | Складання звіту по проекту | 1d | 2009-06-04 | 2009-06-04 | 96, 98 |  |  | 2009-06-04 | 2009-06-04 | 1d | 0d |  | start no earlier than 2009-06-04 | ИКТ [1 шт.]; менеджер по персоналу | 8h |  | 84 | 84 |
| 100 | 1.8.5 | Підготовка рекомендацій | 1d | 2009-06-05 | 2009-06-05 | 99 |  |  | 2009-06-05 | 2009-06-05 | 1d | 0d |  |  | ИКТ [1 шт.]; менеджер по персоналу | 8h |  | 84 | 84 |
